# VehicleFabricationSchedule

Schedule from MS Project, 2004-12-27 to 2005-01-18, 9 hours a day.
MBARI

## Calendars

- Standard: Mon-Fri 08:00-12:00, 13:00-17:00; Sat-Sun off.

## Resources

| Resource |
| --- |
| AUV Fabricator #1 |

## Schedule

| ID | WBS | Task | Duration | Start | Finish | Total slack | Resources | Work |
| --- | --- | --- | --- | --- | --- | --- | --- | --- |
| 1 | 1 | **AUV Fabrication** | 15d | 2004-12-27 08:00 | 2005-01-18 16:00 | 0d |  | 1143h |
| 2 | 1.1 | **SubSystem Ordering/Fabrication** | 2d | 2004-12-27 08:00 | 2004-12-29 10:00 | 13d | AUV Fabricator #1 | 207h |
| 3 | 1.1.1 | **Pressure Vessel Fabrication** | 0.5d | 2004-12-27 08:00 | 2004-12-27 13:30 | 14.5d | AUV Fabricator #1 | 27h |
| 4 | 1.1.1.1 | **MVC Sphere** | 0.5d | 2004-12-27 08:00 | 2004-12-27 13:30 | 14.5d | AUV Fabricator #1 | 11.25h |
| 5 | 1.1.1.1.1 | Quoting & Ordering Benthos sphere | 0.25d | 2004-12-27 08:00 | 2004-12-27 10:15 | 14.75d | AUV Fabricator #1 | 2.25h |
| 6 | 1.1.1.1.2 | Penetrator/dummy kitting for pressure test | 0.5d | 2004-12-27 08:00 | 2004-12-27 13:30 | 14.5d | AUV Fabricator #1 | 4.5h |
| 7 | 1.1.1.2 | **Nose DCON** | 0.5d | 2004-12-27 08:00 | 2004-12-27 13:30 | 14.5d | AUV Fabricator #1 | 11.25h |
| 8 | 1.1.1.2.1 | Quoting & ordering housing | 0.25d | 2004-12-27 08:00 | 2004-12-27 10:15 | 14.75d | AUV Fabricator #1 | 2.25h |
| 9 | 1.1.1.2.2 | Penetrator/dummy kitting for pressure test | 0.5d | 2004-12-27 08:00 | 2004-12-27 13:30 | 14.5d | AUV Fabricator #1 | 4.5h |
| 10 | 1.1.2 | **Fairing Fabrication/Holes** | 1d | 2004-12-27 08:00 | 2004-12-28 09:00 | 14d | AUV Fabricator #1 | 36h |
| 11 | 1.1.2.1 | Tail Fairing | 1d | 2004-12-27 08:00 | 2004-12-28 09:00 | 14d | AUV Fabricator #1 | 9h |
| 12 | 1.1.2.2 | Nose Fairing | 1d | 2004-12-27 08:00 | 2004-12-28 09:00 | 14d | AUV Fabricator #1 | 9h |
| 13 | 1.1.2.3 | MidSection Faiiring | 1d | 2004-12-27 08:00 | 2004-12-28 09:00 | 14d | AUV Fabricator #1 | 9h |
| 14 | 1.1.3 | **Wet Cabling Fabrication** | 0.5d | 2004-12-27 08:00 | 2004-12-27 13:30 | 14.5d | AUV Fabricator #1 | 58.05h |
| 15 | 1.1.3.1 | C/F Kitting for Seaconn | 0.5d | 2004-12-27 08:00 | 2004-12-27 13:30 | 14.5d | AUV Fabricator #1 | 4.5h |
| 16 | 1.1.3.2 | C/F Kitting for Subconn | 0.5d | 2004-12-27 08:00 | 2004-12-27 13:30 | 14.5d | AUV Fabricator #1 | 4.5h |
| 17 | 1.1.3.3 | C/F Kitting for Burton | 0.5d | 2004-12-27 08:00 | 2004-12-27 13:30 | 14.5d | AUV Fabricator #1 | 4.5h |
| 18 | 1.1.3.4 | C/F Kitting for Impulse | 0.5d | 2004-12-27 08:00 | 2004-12-27 13:30 | 14.5d | AUV Fabricator #1 | 4.5h |
| 19 | 1.1.3.5 | MVC Forward Bus Cable | 0.1d | 2004-12-27 08:00 | 2004-12-27 08:54 | 14.9d | AUV Fabricator #1 | 0.9h |
| 20 | 1.1.3.6 | MVC Shore Tether Cable | 0.05d | 2004-12-27 08:00 | 2004-12-27 08:27 | 14.95d | AUV Fabricator #1 | 0.45h |
| 21 | 1.1.3.7 | MVC/TailCone Cable | 0.05d | 2004-12-27 08:00 | 2004-12-27 08:27 | 14.95d | AUV Fabricator #1 | 0.45h |
| 22 | 1.1.3.8 | MVC/DVL Cable | 0.05d | 2004-12-27 08:00 | 2004-12-27 08:27 | 14.95d | AUV Fabricator #1 | 0.45h |
| 23 | 1.1.3.9 | MVC/Pressure Sensor Cable | 0.05d | 2004-12-27 08:00 | 2004-12-27 08:27 | 14.95d | AUV Fabricator #1 | 0.45h |
| 24 | 1.1.3.10 | Battery JBOX Aft Cable | 0.05d | 2004-12-27 08:00 | 2004-12-27 08:27 | 14.95d | AUV Fabricator #1 | 0.45h |
| 25 | 1.1.3.11 | Battery JBOX Forward Cable | 0.05d | 2004-12-27 08:00 | 2004-12-27 08:27 | 14.95d | AUV Fabricator #1 | 0.45h |
| 26 | 1.1.3.12 | Science DCON Aft Cable | 0.05d | 2004-12-27 08:00 | 2004-12-27 08:27 | 14.95d | AUV Fabricator #1 | 0.45h |
| 27 | 1.1.3.13 | CTD1 Cable | 0.5d | 2004-12-27 08:00 | 2004-12-27 13:30 | 14.5d | AUV Fabricator #1 | 4.5h |
| 28 | 1.1.3.14 | CTD2 Cable | 0.5d | 2004-12-27 08:00 | 2004-12-27 13:30 | 14.5d | AUV Fabricator #1 | 4.5h |
| 29 | 1.1.3.15 | DO Sensor Cable | 0.5d | 2004-12-27 08:00 | 2004-12-27 13:30 | 14.5d | AUV Fabricator #1 | 4.5h |
| 30 | 1.1.3.16 | ISUS Cable | 0.5d | 2004-12-27 08:00 | 2004-12-27 13:30 | 14.5d | AUV Fabricator #1 | 4.5h |
| 31 | 1.1.3.17 | Flow Sensor Cable | 0.5d | 2004-12-27 08:00 | 2004-12-27 13:30 | 14.5d | AUV Fabricator #1 | 4.5h |
| 32 | 1.1.3.18 | Biolume Cable | 0.5d | 2004-12-27 08:00 | 2004-12-27 13:30 | 14.5d | AUV Fabricator #1 | 4.5h |
| 33 | 1.1.3.19 | LISST Cable | 0.5d | 2004-12-27 08:00 | 2004-12-27 13:30 | 14.5d | AUV Fabricator #1 | 4.5h |

| ID | WBS | Task | Type | Duration | Start | Finish | Predecessors | Total slack | Resources | Work |
| --- | --- | --- | --- | --- | --- | --- | --- | --- | --- | --- |
| 34 | 1.1.4 | **Syntactic Fabrication** |  | 0.25d | 2004-12-27 08:00 | 2004-12-27 10:15 |  | 14.75d | AUV Fabricator #1 | 6.75h |
| 35 | 1.1.4.1 | Drawing Package Preparation |  | 0.25d | 2004-12-27 08:00 | 2004-12-27 10:15 |  | 14.75d | AUV Fabricator #1 | 2.25h |
| 36 | 1.1.4.2 | Vendor Quoting/Contracting |  | 0.25d | 2004-12-27 08:00 | 2004-12-27 10:15 |  | 14.75d | AUV Fabricator #1 | 2.25h |
| 37 | 1.1.4.3 | Syntactic Module Fabrication | milestone | 0d | 2004-12-27 08:00 | 2004-12-27 08:00 |  | 15d | AUV Fabricator #1 |  |
| 38 | 1.1.5 | **Custom Printed Circuit Board Fabrication** |  | 2d | 2004-12-27 08:00 | 2004-12-29 10:00 |  | 13d | AUV Fabricator #1 | 61.2h |
| 39 | 1.1.5.1 | **MVC Power Board Fabrication** |  | 2d | 2004-12-27 08:00 | 2004-12-29 10:00 |  | 13d | AUV Fabricator #1 | 42.75h |
| 40 | 1.1.5.1.1 | Component ordering |  | 0.25d | 2004-12-27 08:00 | 2004-12-27 10:15 |  | 14.75d | AUV Fabricator #1 | 2.25h |
| 41 | 1.1.5.1.2 | Component installation |  | 2d | 2004-12-27 08:00 | 2004-12-29 10:00 |  | 13d | AUV Fabricator #1 | 18h |
| 42 | 1.1.5.1.3 | Burn-in & test |  | 0.5d | 2004-12-27 08:00 | 2004-12-27 13:30 |  | 14.5d | AUV Fabricator #1 | 4.5h |
| 43 | 1.1.5.2 | Junction Box PCB Fabrication |  | 0.05d | 2004-12-27 08:00 | 2004-12-27 08:27 |  | 14.95d | AUV Fabricator #1 | 0.45h |
| 44 | 1.2 | **Tail Section Electrical/Mechanical Integration & Test** |  | 15d | 2004-12-27 08:00 | 2005-01-18 16:00 |  | 0d | AUV Fabricator #1 | 612h |
| 45 | 1.2.1 | **Tail Bracketry Fabrication** |  | 4d | 2004-12-27 08:00 | 2004-12-31 12:00 |  | 10d | AUV Fabricator #1 | 126h |
| 46 | 1.2.1.1 | Forward Plate |  | 1d | 2004-12-27 08:00 | 2004-12-28 09:00 |  | 13d | AUV Fabricator #1 | 9h |
| 47 | 1.2.1.2 | Bottom Plate |  | 2d | 2004-12-27 08:00 | 2004-12-29 10:00 |  | 12d | AUV Fabricator #1 | 18h |
| 48 | 1.2.1.3 | Aft Plate |  | 1d | 2004-12-27 08:00 | 2004-12-28 09:00 |  | 13d | AUV Fabricator #1 | 9h |
| 49 | 1.2.1.4 | Mounting Clamps (DVL,parosci,homerpro,xpndr) |  | 4d | 2004-12-27 08:00 | 2004-12-31 12:00 |  | 10d | AUV Fabricator #1 | 36h |
| 50 | 1.2.1.5 | Antenna/strobe mount |  | 2d | 2004-12-27 08:00 | 2004-12-29 10:00 |  | 12d | AUV Fabricator #1 | 18h |
| 51 | 1.2.2 | Propulsion Integration/Installation |  | 5d | 2004-12-27 08:00 | 2005-01-03 14:00 |  | 9d | AUV Fabricator #1 | 45h |
| 52 | 1.2.3 | **MVC Sphere/Dry Integation** |  | 14d | 2004-12-27 08:00 | 2005-01-17 15:00 |  | 0d | AUV Fabricator #1 | 252h |
| 53 | 1.2.3.1 | Threaded Insert Frame Fabrication |  | 1d | 2004-12-27 08:00 | 2004-12-28 09:00 |  | 0d | AUV Fabricator #1 | 9h |
| 54 | 1.2.3.2 | Urethane Base Molding |  | 1d | 2004-12-28 09:00 | 2004-12-29 10:00 | 53 | 0d | AUV Fabricator #1 | 9h |
| 55 | 1.2.3.3 | Mounting Plate Installation |  | 1d | 2004-12-29 10:00 | 2004-12-30 11:00 | 54 | 0d | AUV Fabricator #1 | 9h |
| 56 | 1.2.3.4 | PC104 Stack Intallation |  | 0.25d | 2004-12-30 11:00 | 2004-12-30 14:15 | 55 | 0d | AUV Fabricator #1 | 2.25h |
| 57 | 1.2.3.5 | Novatech Installation |  | 0.25d | 2004-12-30 14:15 | 2004-12-30 16:30 | 56 | 0d | AUV Fabricator #1 | 2.25h |
| 58 | 1.2.3.6 | GPS Installation |  | 0.25d | 2004-12-30 16:30 | 2004-12-31 09:45 | 57 | 0d | AUV Fabricator #1 | 2.25h |
| 59 | 1.2.3.7 | Heading Reference Installation |  | 0.25d | 2004-12-31 09:45 | 2004-12-31 12:00 | 58 | 0d | AUV Fabricator #1 | 2.25h |
| 60 | 1.2.3.8 | RF Penetrator Installation/Wiring |  | 0.5d | 2004-12-31 13:00 | 2005-01-03 08:30 | 59 | 0d | AUV Fabricator #1 | 4.5h |
| 61 | 1.2.3.9 | MINK Penetrator Installation/Wiring |  | 2d | 2005-01-03 08:30 | 2005-01-05 10:30 | 60 | 0d | AUV Fabricator #1 | 18h |
| 62 | 1.2.3.10 | LPBH Installation/Wiring |  | 2d | 2005-01-05 10:30 | 2005-01-07 13:30 | 61 | 0d | AUV Fabricator #1 | 18h |
| 63 | 1.2.3.11 | MVC Power Board Installation |  | 0.5d | 2005-01-07 13:30 | 2005-01-10 09:00 | 62 | 0d | AUV Fabricator #1 | 4.5h |
| 64 | 1.2.3.12 | Point-to-Point Wiring Installation |  | 5d | 2005-01-10 09:00 | 2005-01-17 15:00 | 63 | 0d | AUV Fabricator #1 | 45h |

| ID | WBS | Task | Duration | Start | Finish | Predecessors | Total slack | Free slack | Resources | Work |
| --- | --- | --- | --- | --- | --- | --- | --- | --- | --- | --- |
| 65 | 1.2.4 | **Mechanical/Wet Integration** | 2d | 2004-12-27 08:00 | 2004-12-29 10:00 |  | 12d |  | AUV Fabricator #1 | 36h |
| 66 | 1.2.4.1 | Mount Sphere to base plate | 1d | 2004-12-27 08:00 | 2004-12-28 09:00 |  | 12d | 0d | AUV Fabricator #1 | 9h |
| 67 | 1.2.4.2 | Mount/cable Parosci, HomerPro | 0.25d | 2004-12-28 09:00 | 2004-12-28 11:15 | 66 | 12d | 0d | AUV Fabricator #1 | 2.25h |
| 68 | 1.2.4.3 | Mount USBL Beacon/Transducer | 0.25d | 2004-12-28 11:15 | 2004-12-28 14:30 | 67 | 12d | 0d | AUV Fabricator #1 | 2.25h |
| 69 | 1.2.4.4 | Mount/Cable DVL | 0.25d | 2004-12-28 14:30 | 2004-12-28 16:45 | 68 | 12d | 0d | AUV Fabricator #1 | 2.25h |
| 70 | 1.2.4.5 | Syntactic Installation | 0.25d | 2004-12-28 16:45 | 2004-12-29 10:00 | 69 | 12d |  | AUV Fabricator #1 | 2.25h |
| 71 | 1.2.5 | **Functional test of Tail Section sub-systems** | 1d | 2005-01-17 15:00 | 2005-01-18 16:00 | 65, 52, 45, 51 | 0d |  | AUV Fabricator #1 | 18h |
| 72 | 1.2.5.1 | Tailcone Calibration | 0.25d | 2005-01-17 15:00 | 2005-01-18 08:15 |  | 0d |  | AUV Fabricator #1 | 2.25h |
| 73 | 1.2.5.2 | DVL Comms and Rub Test | 0.25d | 2005-01-18 08:15 | 2005-01-18 10:30 | 72 | 0d |  | AUV Fabricator #1 | 2.25h |
| 74 | 1.2.5.3 | Parosci Test | 0.25d | 2005-01-18 10:30 | 2005-01-18 13:45 | 73 | 0d |  | AUV Fabricator #1 | 2.25h |
| 75 | 1.2.5.4 | Crossbow comms test | 0.25d | 2005-01-18 13:45 | 2005-01-18 16:00 | 74 | 0d |  | AUV Fabricator #1 | 2.25h |
| 76 | 1.3 | **Mid Section Electrical/Mechanical Integration & Test** | 8d | 2004-12-27 08:00 | 2005-01-06 17:00 |  | 7d |  | AUV Fabricator #1 | 189h |
| 77 | 1.3.1 | **Bracketry** | 8d | 2004-12-27 08:00 | 2005-01-06 17:00 |  | 7d |  | AUV Fabricator #1 | 72h |
| 78 | 1.3.1.1 | Bracketry Fabrication | 8d | 2004-12-27 08:00 | 2005-01-06 17:00 |  | 7d |  |  |  |
| 79 | 1.3.1.2 | Bracketry assembly | 2d | 2004-12-27 08:00 | 2004-12-29 10:00 |  | 13d |  |  |  |
| 80 | 1.3.2 | Syntactic Assembly | 1d | 2004-12-27 08:00 | 2004-12-28 09:00 |  | 14d |  | AUV Fabricator #1 | 9h |
| 81 | 1.3.3 | **Battery** | 2d | 2004-12-27 08:00 | 2004-12-29 10:00 |  | 13d |  | AUV Fabricator #1 | 18h |
| 82 | 1.3.3.1 | Bench testing | 2d | 2004-12-27 08:00 | 2004-12-29 10:00 |  | 13d |  |  |  |
| 83 | 1.3.3.2 | Installation | 1d | 2004-12-27 08:00 | 2004-12-28 09:00 |  | 14d |  |  |  |
| 84 | 1.3.4 | **junction Box** | 2d | 2004-12-27 08:00 | 2004-12-29 10:00 |  | 13d |  | AUV Fabricator #1 | 18h |
| 85 | 1.3.4.1 | Assembly | 2d | 2004-12-27 08:00 | 2004-12-29 10:00 |  | 13d |  |  |  |
| 86 | 1.3.4.2 | Casting | 1d | 2004-12-27 08:00 | 2004-12-28 09:00 |  | 14d |  |  |  |
| 87 | 1.3.4.3 | Installation | 0.5d | 2004-12-27 08:00 | 2004-12-27 13:30 |  | 14.5d |  |  |  |
| 88 | 1.4 | Nose Section Electrical/Mechanical Integration & Test | 15d | 2004-12-27 08:00 | 2005-01-18 16:00 |  | 0d |  | AUV Fabricator #1 | 135h |
